# PAQUETE R-07 DEFENSAS RIBEREÑAS DEL RÍO LACRAMARCA

Schedule from Primavera P6, 2024-11-15 to 2025-05-29, data date 2024-11-15, costs in PEN.

## Calendars

- Lacramarca (7d/10h): Mon-Sun 08:00-16:00. Exceptions (off unless hours are given): 2024-11-15 to 2025-05-29 07:00-12:00, 13:00-18:00.

## Resources

| Resource | Group | Rate |
| --- | --- | --- |
| Recurso Lacramarca | labor | 1 |
| Recurso Lacramarca - NLU | equipment |  |

## Schedule

| ID | WBS | Activity | Type | Duration | Start | Finish | Predecessors | Total float | Free float | Resources | Cost | Lacramarca |
| --- | --- | --- | --- | --- | --- | --- | --- | --- | --- | --- | --- | --- |
| C.00.00.01 |  | Kick off Meeting (KOM) | milestone | 0d | 2024-11-15 | 2024-11-15 |  | 0d |  |  |  |  |
|  | 501 | **DEFENSAS RIBEREÑAS** |  |  | 2024-12-01 | 2025-05-29 |  |  |  |  |  |  |
|  | C | **CONSTRUCCIÓN** |  |  | 2024-12-01 | 2025-05-29 |  |  |  |  |  |  |
|  | 00 | **GENERAL** |  |  | 2024-12-01 | 2025-05-29 |  |  |  |  |  |  |
|  | 00 | **GENERAL** |  |  | 2024-12-01 | 2025-05-29 |  |  |  |  |  |  |
| C.00.00.02 |  | Inicio de plazo contractual - Acceso al Sitio | milestone | 0d | 2024-12-01 | 2024-12-01 | C.00.00.01 FS+16d | 0d |  |  |  |  |
| C.00.00.03 |  | Inicio de excavación | milestone | 0d | 2024-12-06 | 2024-12-06 | C.70.10.01.01.10 SS | 14d |  |  |  |  |
| C.00.00.04 |  | Inicio de relleno de dique | milestone | 0d | 2024-12-20 | 2024-12-20 | C.70.10.01.01.30 SS | 5d |  |  |  |  |
| C.00.00.05 |  | Fin de plazo contractual - Culminación de obras | milestone | 0d | 2025-05-29 | 2025-05-29 | C.70.00.20 FF | 0d |  |  |  |  |
|  | 70 | **OBRAS EXTERIORES** |  |  | 2024-12-01 | 2025-05-29 |  |  |  |  |  |  |
|  | 00 | **GENERAL** |  |  | 2024-12-01 | 2025-05-29 |  |  |  |  |  |  |
| C.70.00.10 |  | Inicio del Proyecto | milestone | 0d | 2024-12-01 | 2024-12-01 | C.00.00.02 SS | 0d |  |  |  |  |
| C.70.00.20 |  | Fin del Proyecto | milestone | 0d | 2025-05-29 | 2025-05-29 | C.70.10.02.03.02.30, C.70.10.02.03.02.40, C.70.10.02.03.01.70, C.70.10.02.03.01.80, C.70.10.02.03.02.70, C.70.10.02.03.02.80, C.70.10.02.03.02.20, C.70.10.02.03.02.50, C.70.10.02.03.02.60, C.70.13.10, C.70.13.20, C.70.17.10, C.70.17.20, C.70.17.30, C.70.17.40, C.70.02.01, C.70.30.01, T.20.20.01, C.70.13.30, C.70.01.02 | 0d |  |  |  |  |
|  | 01 | **PREPARACIÓN DE SITIO** |  |  | 2024-12-01 | 2025-05-29 |  |  |  |  |  |  |
| C.70.01.01 |  | Obras provisionales |  | 5d | 2024-12-01 | 2024-12-05 | C.70.00.10 | 0d |  | Recurso Lacramarca [437278 h]; Recurso Lacramarca - NLU [46.48 h] | 437,278.28 |  |
| C.70.01.02 |  | Topografía | level of effort | 175d | 2024-12-06 | 2025-05-29 | C.70.01.01 | 0d |  | Recurso Lacramarca [1655871 h]; Recurso Lacramarca - NLU [12123.5 h] | 1,655,870.6 |  |
|  | 02 | **CAMINOS PROVISIONALES** |  |  | 2024-12-06 | 2025-05-29 |  |  |  |  |  |  |
| C.70.02.01 |  | Mantenimiento de tránsito y seguridad vial | level of effort | 175d | 2024-12-06 | 2025-05-29 | C.70.01.01 | 0d |  | Recurso Lacramarca [2327293 h]; Recurso Lacramarca - NLU [13166.8 h] | 2,327,293.01 |  |
|  | 03 | **PLANTACIÓN Y PAISAJISMO** |  |  | 2025-03-24 | 2025-05-29 |  |  |  |  |  |  |
| C.70.30.01 |  | Arquitectura y paisajismo | level of effort | 67d | 2025-03-24 | 2025-05-29 | C.70.10.02.02.80, C.70.10.02.02.70 | 0d |  | Recurso Lacramarca [129019 h]; Recurso Lacramarca - NLU [606.63 h] | 129,019.35 |  |
|  | 10 | **CUERPOS DE TERRAPLÉN** |  |  | 2024-12-06 | 2025-05-29 |  |  |  |  |  |  |
|  | 01 | **MARGEN DERECHO** |  |  | 2024-12-06 | 2025-03-06 |  |  |  |  |  |  |
|  | 01 | **TERRAPLÉN A3-D-01** |  |  | 2024-12-06 | 2025-01-20 |  |  |  |  |  |  |
| C.70.10.01.01.10 |  | Descolmatación (C1) - 1er Tramo |  | 12d | 2024-12-06 | 2024-12-17 | C.70.01.01 | 0d |  | Recurso Lacramarca [248213 h]; Recurso Lacramarca - NLU [1193.7 h] | 248,212.68 | D |
| C.70.10.01.01.20 |  | Excavación (C1) - 1er Tramo |  | 4d | 2024-12-16 | 2024-12-19 | C.70.10.01.01.10 SS+10d, C.70.01.01 | 0d |  | Recurso Lacramarca [36848.2 h]; Recurso Lacramarca - NLU [252.35 h] | 36,848.21 | E |
| C.70.10.01.01.30 |  | Relleno de Cuerpo (C1) - 1er Tramo |  | 11d | 2024-12-20 | 2024-12-30 | C.70.10.01.01.20, C.70.10.01.01.10, C.70.01.01, C.00.00.03 SS | 0d |  | Recurso Lacramarca [28489.3 h]; Recurso Lacramarca - NLU [189.32 h] | 28,489.29 | R |
| C.70.10.01.01.40 |  | Relleno de Corona (C1) - 1er Tramo |  | 7d | 2024-12-25 | 2024-12-31 | C.70.10.01.01.20, C.70.10.01.01.10, C.70.01.01, C.70.10.01.01.30 SS+5d, C.00.00.04 | 0d |  | Recurso Lacramarca [299624 h]; Recurso Lacramarca - NLU [2406.06 h] | 299,624.39 | R1 |
| C.70.10.01.01.50 |  | Excavación de Uña (C1) - 1er Tramo |  | 2d | 2025-01-01 | 2025-01-02 | C.70.10.01.01.10, C.70.01.01, C.70.10.01.01.20, C.70.10.01.01.30 SS+12d, C.70.10.01.01.40 | 0d |  | Recurso Lacramarca [261796 h]; Recurso Lacramarca - NLU [2242.73 h] | 261,796.03 | E1 |
| C.70.10.01.01.60 |  | Geotextil (C1) -1er Tramo |  | 6d | 2025-01-02 | 2025-01-07 | C.70.10.01.01.10, C.70.10.01.01.20, C.70.10.01.01.50 SS+1d | 0d |  | Recurso Lacramarca [57014.9 h]; Recurso Lacramarca - NLU [310.95 h] | 57,014.92 | G |
| C.70.10.01.01.70 |  | Enrocado de Uña (C1) - 1er Tramo |  | 11d | 2025-01-03 | 2025-01-13 | C.70.10.01.01.60 SS+1d, C.70.10.01.01.20, C.70.10.01.01.50, C.70.10.01.01.30, C.70.10.01.01.40, C.70.10.01.01.10 | 5d | 0d | Recurso Lacramarca [338409 h]; Recurso Lacramarca - NLU [3156.47 h] | 338,408.97 | N |
| C.70.10.01.01.80 |  | Enrocado de Talud (C1) - 1er Tramo |  | 16d | 2025-01-05 | 2025-01-20 | C.70.10.01.01.20, C.70.10.01.01.50, C.70.10.01.01.30, C.70.10.01.01.40, C.70.10.01.01.10, C.70.10.01.01.70 SS+2d | 5d | 0d | Recurso Lacramarca [385643 h]; Recurso Lacramarca - NLU [3420.36 h] | 385,643.2 | N1 |

| ID | WBS | Activity | Duration | Start | Finish | Predecessors | Total float | Free float | Resources | Cost | Lacramarca |
| --- | --- | --- | --- | --- | --- | --- | --- | --- | --- | --- | --- |
|  | 02 | **TERRAPLÉN A3-D-02** |  | 2024-12-06 | 2025-03-06 |  |  |  |  |  |  |
|  | 01 | **Tramo 01** |  | 2024-12-18 | 2025-01-29 |  |  |  |  |  |  |
| C.70.10.01.02.01.10 |  | Descolmatación (C1) - 1er Tramo | 2d | 2024-12-18 | 2024-12-19 | C.70.10.01.01.10, C.70.01.01 | 11d | 0d | Recurso Lacramarca [36434.8 h]; Recurso Lacramarca - NLU [175.03 h] | 36,434.76 | D |
| C.70.10.01.02.01.20 |  | Excavación (C1) - 1er Tramo | 2d | 2024-12-20 | 2024-12-21 | C.70.10.01.01.20, C.70.01.01, C.70.10.01.02.01.10 | 11d | 0d | Recurso Lacramarca [11933.2 h]; Recurso Lacramarca - NLU [82.28 h] | 11,933.25 | E |
| C.70.10.01.02.01.30 |  | Relleno de Cuerpo (C1) - 1er Tramo | 2d | 2024-12-31 | 2025-01-01 | C.70.10.01.01.30, C.70.01.01, C.70.10.01.02.01.20 | 2d | 0d | Recurso Lacramarca [10570.3 h]; Recurso Lacramarca - NLU [70.47 h] | 10,570.3 | R |
| C.70.10.01.02.01.40 |  | Relleno de Corona (C1) - 1er Tramo | 1d | 2025-01-02 | 2025-01-02 | C.70.10.01.01.40, C.70.01.01, C.70.10.01.02.01.30 | 5d |  | Recurso Lacramarca [63852.4 h]; Recurso Lacramarca - NLU [520.04 h] | 63,852.37 | R1 |
| C.70.10.01.02.01.50 |  | Excavación de Uña (C1) - 1er Tramo | 1d | 2025-01-03 | 2025-01-03 | C.70.10.01.01.50, C.70.01.01, C.70.10.01.02.01.30 | 1d | 0d | Recurso Lacramarca [58576.3 h]; Recurso Lacramarca - NLU [500.83 h] | 58,576.35 | E1 |
| C.70.10.01.02.01.60 |  | Geotextil (C1) -1er Tramo | 1d | 2025-01-08 | 2025-01-08 | C.70.10.01.01.60, C.70.10.01.02.01.30, C.70.10.01.02.01.40, C.70.10.01.02.01.50 | 0d |  | Recurso Lacramarca [12291.2 h]; Recurso Lacramarca - NLU [67.03 h] | 12,291.23 | G |
| C.70.10.01.02.01.70 |  | Enrocado de Uña (C1) - 1er Tramo | 7d | 2025-01-14 | 2025-01-20 | C.70.10.01.01.70, C.70.10.01.02.01.60, C.70.10.01.02.01.30, C.70.10.01.02.01.40, C.70.10.01.02.01.10, C.70.10.01.02.01.20, C.70.10.01.02.01.50 | 31d | 0d | Recurso Lacramarca [127764 h]; Recurso Lacramarca - NLU [1076.75 h] | 127,764.23 | N |
| C.70.10.01.02.01.80 |  | Enrocado de Talud (C1) - 1er Tramo | 9d | 2025-01-21 | 2025-01-29 | C.70.10.01.01.80, C.70.10.01.01.70, C.70.10.01.02.01.60, C.70.10.01.02.01.30, C.70.10.01.02.01.40, C.70.10.01.02.01.10, C.70.10.01.02.01.20, C.70.10.01.02.01.50, C.70.10.01.02.01.70 | 31d | 4d | Recurso Lacramarca [140844 h]; Recurso Lacramarca - NLU [1150.52 h] | 140,844.29 | N1 |
|  | 02 | **Tramo 02** |  | 2024-12-20 | 2025-03-02 |  |  |  |  |  |  |
| C.70.10.01.02.02.10 |  | Descolmatación (C1) - 2do Tramo | 15d | 2024-12-20 | 2025-01-03 | C.70.10.01.02.01.10, C.70.01.01 | 22d | 21d | Recurso Lacramarca [728695 h]; Recurso Lacramarca - NLU [3500.51 h] | 728,695.21 | D |
| C.70.10.01.02.02.20 |  | Excavación (C1) - 2do Tramo | 15d | 2024-12-22 | 2025-01-05 | C.70.10.01.02.01.20, C.70.01.01, C.70.10.01.01.20 | 28d | 19d | Recurso Lacramarca [113366 h]; Recurso Lacramarca - NLU [781.65 h] | 113,365.89 | E |
| C.70.10.01.02.02.30 |  | Relleno de Cuerpo (C1) - 2do Tramo | 22d | 2025-01-02 | 2025-01-23 | C.70.10.01.02.01.30, C.70.10.01.01.30, C.70.01.01 | 3d | 0d | Recurso Lacramarca [100418 h]; Recurso Lacramarca - NLU [669.47 h] | 100,417.78 | R |
| C.70.10.01.02.02.40 |  | Relleno de Corona (C1) - 2do Tramo | 17d | 2025-01-09 | 2025-01-25 | C.70.10.01.02.01.40, C.70.10.01.01.30, C.70.10.01.01.40, C.70.01.01, C.70.10.01.02.02.30 SS+7d | 17d | 3d | Recurso Lacramarca [670450 h]; Recurso Lacramarca - NLU [5460.35 h] | 670,449.84 | R1 |
| C.70.10.01.02.02.50 |  | Excavación de Uña (C1) - 2do Tramo | 16d | 2025-01-15 | 2025-01-30 | C.70.10.01.02.01.50, C.70.01.01, C.70.10.01.02.02.30 SS+13d | 3d | 0d | Recurso Lacramarca [615052 h]; Recurso Lacramarca - NLU [5258.59 h] | 615,051.6 | E1 |
| C.70.10.01.02.02.60 |  | Geotextil (C1) -2do Tramo | 9d | 2025-01-25 | 2025-02-02 | C.70.10.01.02.01.60, C.70.10.01.02.02.50 SS+10d, C.70.10.01.01.60, C.70.10.01.02.02.10, C.70.10.01.02.02.20 | 27d | 0d | Recurso Lacramarca [86038.6 h]; Recurso Lacramarca - NLU [469.24 h] | 86,038.61 | G |
| C.70.10.01.02.02.70 |  | Enrocado de Uña (C3,C4) - 2do Tramo | 23d | 2025-01-29 | 2025-02-20 | C.70.10.01.02.01.70, C.70.10.01.02.02.60 SS+4d, C.70.10.01.02.02.30, C.70.10.01.02.02.40, C.70.10.01.02.02.10, C.70.10.01.02.02.20 | 35d | 17d | Recurso Lacramarca [411685 h]; Recurso Lacramarca - NLU [3469.51 h] | 411,684.74 | N |
| C.70.10.01.02.02.80 |  | Enrocado de Talud (C3,C4) - 2do Tramo | 28d | 2025-02-03 | 2025-03-02 | C.70.10.01.02.01.70, C.70.10.01.02.01.80, C.70.10.01.02.02.60, C.70.10.01.02.02.30, C.70.10.01.02.02.40, C.70.10.01.02.02.10, C.70.10.01.02.02.20, C.70.10.01.02.02.50 | 27d | 7d | Recurso Lacramarca [453832 h]; Recurso Lacramarca - NLU [3707.23 h] | 453,831.61 | N1 |
|  | 03 | **Tramo 03** |  | 2024-12-06 | 2025-03-06 |  |  |  |  |  |  |
| C.70.10.01.02.03.10 |  | Descolmatación (C2) - 3er Tramo | 15d | 2024-12-06 | 2024-12-20 | C.70.01.01 | 2d | 0d | Recurso Lacramarca [728695 h]; Recurso Lacramarca - NLU [3500.51 h] | 728,695.21 | D |
| C.70.10.01.02.03.20 |  | Excavación (C2) - 3er Tramo | 15d | 2024-12-11 | 2024-12-25 | C.70.01.01, C.70.10.01.02.03.10 SS+5d | 2d | 0d | Recurso Lacramarca [107399 h]; Recurso Lacramarca - NLU [740.52 h] | 107,399.25 | E |
| C.70.10.01.02.03.30 |  | Relleno de Cuerpo (C2) - 3er Tramo | 22d | 2024-12-21 | 2025-01-11 | C.70.10.01.02.03.20 SS+10d, C.70.10.01.02.03.10 SS+15d, C.70.01.01 | 2d | 1d | Recurso Lacramarca [95132.6 h]; Recurso Lacramarca - NLU [634.24 h] | 95,132.63 | R |
| C.70.10.01.02.03.40 |  | Relleno de Corona (C2) - 3er Tramo | 17d | 2024-12-26 | 2025-01-11 | C.70.10.01.02.03.20, C.70.10.01.02.03.10, C.70.01.01 | 14d |  | Recurso Lacramarca [670450 h]; Recurso Lacramarca - NLU [5460.35 h] | 670,449.84 | R1 |
| C.70.10.01.02.03.50 |  | Excavación de Uña (C2) - 3er Tramo | 16d | 2025-01-04 | 2025-01-19 | C.70.10.01.02.01.50, C.70.01.01, C.70.10.01.01.20, C.70.10.01.02.03.30 SS+13d | 1d |  | Recurso Lacramarca [615052 h]; Recurso Lacramarca - NLU [5258.59 h] | 615,051.6 | E1 |
| C.70.10.01.02.03.60 |  | Geotextil (C2) -3er Tramo | 17d | 2025-01-09 | 2025-01-25 | C.70.10.01.02.01.60, C.70.10.01.02.03.10, C.70.10.01.01.60, C.70.10.01.02.03.50 SS+4d | 0d |  | Recurso Lacramarca [159786 h]; Recurso Lacramarca - NLU [871.45 h] | 159,785.98 | G |
| C.70.10.01.02.03.70 |  | Enrocado de Uña (C1,C2) - 3er Tramo | 46d | 2025-01-10 | 2025-02-24 | C.70.10.01.02.03.60 SS+1d, C.70.10.01.02.03.10, C.70.10.01.02.03.20 | 21d | 0d | Recurso Lacramarca [851762 h]; Recurso Lacramarca - NLU [7178.29 h] | 851,761.53 | N |
| C.70.10.01.02.03.80 |  | Enrocado de Talud (C1,C2) - 3er Tramo | 55d | 2025-01-11 | 2025-03-06 | C.70.10.01.02.03.10, C.70.10.01.02.03.70 SS+1d | 21d |  | Recurso Lacramarca [938962 h]; Recurso Lacramarca - NLU [7670.05 h] | 938,961.83 | N1 |

| ID | WBS | Activity | Duration | Start | Finish | Predecessors | Total float | Free float | Resources | Cost | Lacramarca |
| --- | --- | --- | --- | --- | --- | --- | --- | --- | --- | --- | --- |
|  | 02 | **MARGEN IZQUIERDO** |  | 2025-01-26 | 2025-05-29 |  |  |  |  |  |  |
|  | 01 | **TERRAPLÉN A3-I-01** |  | 2025-01-26 | 2025-03-18 |  |  |  |  |  |  |
| C.70.10.02.01.10 |  | Descolmatación (C1) - 1er Tramo | 20d | 2025-01-26 | 2025-02-14 | C.70.10.01.01.70, C.70.10.01.01.80, C.70.10.01.01.10, C.70.10.01.02.02.10, C.70.10.01.02.03.10, C.70.01.01, C.70.10.01.02.01.10, C.70.10.01.02.03.20, C.70.10.01.02.03.30, C.70.10.01.02.03.40, C.70.10.01.02.03.50, C.70.10.01.02.03.60 | 0d |  | Recurso Lacramarca [765613 h]; Recurso Lacramarca - NLU [3684.55 h] | 765,612.85 | D |
| C.70.10.02.01.20 |  | Excavación (C1) - 1er Tramo | 16d | 2025-02-03 | 2025-02-18 | C.70.10.02.01.10 SS+8d, C.70.10.01.01.20, C.70.10.01.01.50, C.70.10.01.01.30, C.70.10.01.02.03.20, C.70.10.01.02.03.50, C.70.10.01.02.02.20, C.70.10.01.02.02.50, C.70.01.01, C.70.10.01.02.01.20 | 0d |  | Recurso Lacramarca [37474.4 h]; Recurso Lacramarca - NLU [274.09 h] | 37,474.37 | E |
| C.70.10.02.01.30 |  | Relleno de Cuerpo (C1) - 1er Tramo | 9d | 2025-02-11 | 2025-02-19 | C.70.10.02.01.20 SS+8d, C.70.10.01.01.30, C.70.10.01.01.40, C.70.10.01.02.02.30, C.70.10.01.02.02.40, C.70.10.01.02.03.30, C.70.10.01.02.03.40, C.70.01.01 | 1d | 0d | Recurso Lacramarca [32878.6 h]; Recurso Lacramarca - NLU [236.24 h] | 32,878.58 | R |
| C.70.10.02.01.40 |  | Relleno de Corona (C1) - 1er Tramo | 4d | 2025-02-20 | 2025-02-23 | C.70.10.01.01.30, C.70.10.01.01.40, C.70.10.01.02.02.30, C.70.10.01.02.02.40, C.70.10.01.02.03.30, C.70.10.01.02.03.40, C.70.01.01, C.70.10.02.01.30 | 1d | 0d | Recurso Lacramarca [433514 h]; Recurso Lacramarca - NLU [3390.48 h] | 433,514.32 | R1 |
| C.70.10.02.01.50 |  | Excavación de Uña (C1) - 1er Tramo | 4d | 2025-02-24 | 2025-02-27 | C.70.10.02.01.20, C.70.10.01.01.20, C.70.10.01.01.50, C.70.10.01.02.03.20, C.70.10.01.02.03.50, C.70.10.01.02.02.20, C.70.10.01.02.02.50, C.70.01.01, C.70.10.02.01.30, C.70.10.02.01.40 | 1d | 0d | Recurso Lacramarca [329980 h]; Recurso Lacramarca - NLU [2873.99 h] | 329,979.63 | E1 |
| C.70.10.02.01.60 |  | Geotextil (C1) -1er Tramo | 6d | 2025-02-25 | 2025-03-02 | C.70.10.02.01.40, C.70.10.01.01.60, C.70.10.01.02.01.60, C.70.10.01.02.02.60, C.70.10.01.02.03.60, C.70.10.02.01.50 SS+1d | 12d | 0d | Recurso Lacramarca [55900.1 h]; Recurso Lacramarca - NLU [304.87 h] | 55,900.08 | G |
| C.70.10.02.01.70 |  | Enrocado de Uña (C1) - 1er Tramo | 11d | 2025-02-26 | 2025-03-08 | C.70.10.02.01.60 SS+1d, C.70.10.01.01.70, C.70.10.01.01.80, C.70.10.02.01.10 | 22d | 1d | Recurso Lacramarca [328368 h]; Recurso Lacramarca - NLU [3059.41 h] | 328,368.3 | N |
| C.70.10.02.01.80 |  | Enrocado de Talud (C1) - 1er Tramo | 16d | 2025-03-03 | 2025-03-18 | C.70.10.02.01.60, C.70.10.01.01.80, C.70.10.01.01.70, C.70.10.02.01.10 | 12d | 0d | Recurso Lacramarca [377393 h]; Recurso Lacramarca - NLU [3335.46 h] | 377,392.56 | N1 |
|  | 02 | **TERRAPLÉN A3-I-02** |  | 2025-02-15 | 2025-04-05 |  |  |  |  |  |  |
| C.70.10.02.02.10 |  | Descolmatación (C1) - 2do Tramo | 12d | 2025-02-15 | 2025-02-26 | C.70.10.02.01.10, C.70.01.01, C.70.10.01.02.03.10, C.70.10.01.02.02.10, C.70.10.01.02.01.10, C.70.10.01.01.10 | 0d |  | Recurso Lacramarca [377230 h]; Recurso Lacramarca - NLU [1809.51 h] | 377,230.23 | D |
| C.70.10.02.02.20 |  | Excavación (C1) - 2do Tramo | 11d | 2025-02-19 | 2025-03-01 | C.70.10.02.01.20, C.70.10.02.01.10, C.70.01.01, C.70.10.01.02.03.20, C.70.10.01.02.03.50, C.70.10.01.02.02.20, C.70.10.01.02.02.50, C.70.10.02.02.10 SS+4d, C.70.10.01.02.01.20 | 0d |  | Recurso Lacramarca [47421 h]; Recurso Lacramarca - NLU [349.02 h] | 47,420.99 | E |
| C.70.10.02.02.30 |  | Relleno de Cuerpo (C1) - 2do Tramo | 2d | 2025-03-02 | 2025-03-03 | C.70.10.02.01.30, C.70.10.02.01.40, C.70.10.02.02.20, C.70.01.01, C.70.10.01.02.03.30, C.70.10.01.02.03.40 | 11d | 0d | Recurso Lacramarca [44737.3 h]; Recurso Lacramarca - NLU [321.24 h] | 44,737.29 | R |
| C.70.10.02.02.40 |  | Relleno de Corona (C1) - 2do Tramo | 4d | 2025-03-04 | 2025-03-07 | C.70.10.02.01.30, C.70.10.02.01.40, C.70.10.02.02.20, C.70.01.01, C.70.10.01.02.03.30, C.70.10.01.02.03.40, C.70.10.02.02.30 | 11d | 0d | Recurso Lacramarca [194050 h]; Recurso Lacramarca - NLU [1662.28 h] | 194,049.8 | R1 |
| C.70.10.02.02.50 |  | Excavación de Uña (C1) - 2do Tramo | 6d | 2025-03-08 | 2025-03-13 | C.70.10.02.01.50, C.70.10.02.01.20, C.70.10.02.01.10, C.70.01.01, C.70.10.01.02.03.20, C.70.10.01.02.03.50, C.70.10.01.02.02.20, C.70.10.01.02.02.50, C.70.10.02.02.40 SS+4d | 11d | 0d | Recurso Lacramarca [224314 h]; Recurso Lacramarca - NLU [1870.48 h] | 224,313.89 | E1 |
| C.70.10.02.02.60 |  | Geotextil (C1) -2do Tramo | 6d | 2025-03-09 | 2025-03-14 | C.70.10.02.01.60, C.70.10.02.02.30, C.70.10.02.02.40, C.70.10.01.02.03.60, C.70.10.01.02.02.60, C.70.10.01.02.01.60, C.70.10.01.01.60, C.70.10.02.02.50 SS+1d | 43d | 0d | Recurso Lacramarca [50343.2 h]; Recurso Lacramarca - NLU [274.56 h] | 50,343.2 | G |
| C.70.10.02.02.70 |  | Enrocado de Uña (C1) - 2do Tramo | 14d | 2025-03-10 | 2025-03-23 | C.70.10.02.02.60 SS+1d, C.70.10.02.01.70, C.70.10.01.02.02.70, C.70.10.01.02.02.80 | 52d | 4d | Recurso Lacramarca [415093 h]; Recurso Lacramarca - NLU [3828.17 h] | 415,092.59 | N |
| C.70.10.02.02.80 |  | Enrocado de Talud (C1) - 2do Tramo | 18d | 2025-03-19 | 2025-04-05 | C.70.10.02.02.60, C.70.10.02.01.70, C.70.10.02.01.80, C.70.10.01.02.02.70, C.70.10.01.02.02.80 | 39d | 0d | Recurso Lacramarca [444311 h]; Recurso Lacramarca - NLU [3990.94 h] | 444,310.96 | N1 |
|  | 03 | **TERRAPLÉN A3-I-03** |  | 2025-02-06 | 2025-05-29 |  |  |  |  |  |  |
|  | 01 | **Tramo 03** |  | 2025-02-27 | 2025-04-20 |  |  |  |  |  |  |
| C.70.10.02.03.01.10 |  | Descolmatación (C1) - 3er Tramo | 11d | 2025-02-27 | 2025-03-09 | C.70.10.02.02.10, C.70.01.01, C.70.10.02.01.10, C.70.10.01.02.03.10, C.70.10.01.02.02.10, C.70.10.01.02.01.10, C.70.10.01.01.10 | 48d | 0d | Recurso Lacramarca [250262 h]; Recurso Lacramarca - NLU [1202.36 h] | 250,261.63 | D |
| C.70.10.02.03.01.20 |  | Excavación (C1) - 3er Tramo | 13d | 2025-03-02 | 2025-03-14 | C.70.10.02.02.20, C.70.01.01, C.70.10.02.03.01.10 SS+3d, C.70.10.02.01.20, C.70.10.01.02.03.20, C.70.10.01.02.02.20, C.70.10.01.02.01.20 | 48d | 0d | Recurso Lacramarca [70857.4 h]; Recurso Lacramarca - NLU [500.46 h] | 70,857.39 | E |
| C.70.10.02.03.01.30 |  | Relleno de Cuerpo (C1) - 3er Tramo | 4d | 2025-03-14 | 2025-03-17 | C.70.10.02.02.30, C.70.10.02.02.40, C.70.10.02.03.01.20 SS+12d, C.70.01.01, C.70.10.02.01.30, C.70.10.02.01.40 | 48d | 0d | Recurso Lacramarca [64192.9 h]; Recurso Lacramarca - NLU [440.38 h] | 64,192.86 | R |
| C.70.10.02.03.01.40 |  | Relleno de Corona (C1) - 3er Tramo | 3d | 2025-03-15 | 2025-03-17 | C.70.10.02.02.30, C.70.10.02.02.40, C.70.10.02.03.01.20, C.70.01.01, C.70.10.02.01.30, C.70.10.02.01.40, C.70.10.02.03.01.30 SS+1d, C.70.10.01.02.03.40, C.70.10.01.02.02.40, C.70.10.01.02.01.40, C.70.10.01.01.40 | 58d | 10d | Recurso Lacramarca [226742 h]; Recurso Lacramarca - NLU [1837.59 h] | 226,742.03 | R1 |
| C.70.10.02.03.01.50 |  | Excavación de Uña (C1) - 3er Tramo | 10d | 2025-03-18 | 2025-03-27 | C.70.10.02.02.50, C.70.10.02.03.01.10, C.70.01.01, C.70.10.02.03.01.30 | 48d | 0d | Recurso Lacramarca [207375 h]; Recurso Lacramarca - NLU [1767.23 h] | 207,374.7 | E1 |
| C.70.10.02.03.01.60 |  | Geotextil (C1) -3er Tramo | 5d | 2025-03-23 | 2025-03-27 | C.70.10.02.03.01.20, C.70.10.02.03.01.50 SS+5d, C.70.10.02.01.60, C.70.10.01.02.03.60, C.70.10.01.02.02.60, C.70.10.01.02.01.60, C.70.10.01.01.60, C.70.10.02.02.60 | 48d | 0d | Recurso Lacramarca [27095.7 h]; Recurso Lacramarca - NLU [147.78 h] | 27,095.73 | G |
| C.70.10.02.03.01.70 |  | Enrocado de Uña (C1) - 3er Tramo | 13d | 2025-03-28 | 2025-04-09 | C.70.10.02.03.01.60, C.70.10.02.02.70, C.70.10.02.03.01.30, C.70.10.02.03.01.40 | 50d |  | Recurso Lacramarca [214916 h]; Recurso Lacramarca - NLU [1805.3 h] | 214,915.62 | N |
| C.70.10.02.03.01.80 |  | Enrocado de Talud (C1) - 3er Tramo | 15d | 2025-04-06 | 2025-04-20 | C.70.10.02.03.01.60, C.70.10.02.02.70, C.70.10.02.02.80, C.70.10.02.03.01.30, C.70.10.02.03.01.40 | 39d |  | Recurso Lacramarca [238813 h]; Recurso Lacramarca - NLU [1940.47 h] | 238,812.66 | N1 |

| ID | WBS | Activity | Type | Duration | Start | Finish | Predecessors | Total float | Free float | Resources | Cost | Lacramarca |
| --- | --- | --- | --- | --- | --- | --- | --- | --- | --- | --- | --- | --- |
|  | 02 | **Tramo 04** |  |  | 2025-02-06 | 2025-05-29 |  |  |  |  |  |  |
| C.70.10.02.03.02.10 |  | Descolmatación (C1) - 4to Tramo |  | 32d | 2025-02-06 | 2025-03-09 | C.70.10.02.01.10 SS+11d, C.70.01.01, C.70.10.01.02.03.10, C.70.10.01.02.02.10, C.70.10.01.02.01.10, C.70.10.01.01.10 | 0d |  | Recurso Lacramarca [750785 h]; Recurso Lacramarca - NLU [3607.05 h] | 750,784.88 | D |
| C.70.10.02.03.02.20 |  | Excavación (C1) - 4to Tramo |  | 25d | 2025-02-19 | 2025-03-15 | C.70.10.02.01.20, C.70.10.02.03.02.10 SS+13d, C.70.10.01.02.03.20, C.70.10.01.02.03.50, C.70.01.01, C.70.10.01.02.02.20, C.70.10.01.02.01.20, C.70.10.01.01.20 | 0d |  | Recurso Lacramarca [127543 h]; Recurso Lacramarca - NLU [900.8 h] | 127,543.26 | E |
| C.70.10.02.03.02.30 |  | Relleno de Cuerpo (C1) - 4to Tramo |  | 30d | 2025-03-02 | 2025-03-31 | C.70.10.02.02.20, C.70.01.01, C.70.10.02.03.02.20 SS+11d, C.70.10.01.01.30, C.70.10.01.02.01.30, C.70.10.01.02.02.30, C.70.10.01.02.03.30, C.70.10.02.01.30 | 0d |  | Recurso Lacramarca [115547 h]; Recurso Lacramarca - NLU [792.66 h] | 115,547.12 | R |
| C.70.10.02.03.02.40 |  | Relleno de Corona (C1) - 4to Tramo |  | 22d | 2025-03-11 | 2025-04-01 | C.70.10.02.02.20, C.70.01.01, C.70.10.02.03.02.30 SS+9d, C.70.10.01.01.40, C.70.10.01.02.01.40, C.70.10.01.02.02.40, C.70.10.01.02.03.40, C.70.10.02.01.40 | 0d |  | Recurso Lacramarca [874576 h]; Recurso Lacramarca - NLU [7087.86 h] | 874,576.41 | R1 |
| C.70.10.02.03.02.50 |  | Excavación de Uña (C1) - 4to Tramo |  | 18d | 2025-03-25 | 2025-04-11 | C.70.10.02.01.20, C.70.10.02.01.50, C.70.10.01.02.03.20, C.70.10.01.02.03.50, C.70.01.01, C.70.10.02.03.02.40 SS+14d, C.70.10.02.02.50, C.70.10.01.02.02.50, C.70.10.01.02.01.50, C.70.10.01.01.50 | 0d |  | Recurso Lacramarca [799874 h]; Recurso Lacramarca - NLU [6816.47 h] | 799,873.83 | E1 |
| C.70.10.02.03.02.60 |  | Geotextil (C1) -4to Tramo |  | 18d | 2025-03-26 | 2025-04-12 | C.70.10.02.01.60, C.70.10.02.03.02.10, C.70.10.01.02.03.60, C.70.10.01.02.02.60, C.70.10.01.02.01.60, C.70.10.01.01.60, C.70.10.02.03.02.50 SS+1d | 0d |  | Recurso Lacramarca [182896 h]; Recurso Lacramarca - NLU [997.48 h] | 182,896.2 | G |
| C.70.10.02.03.02.70 |  | Enrocado de Uña (C1) - 4to Tramo |  | 50d | 2025-03-28 | 2025-05-16 | C.70.10.02.03.02.60 SS+2d, C.70.10.02.03.02.10, C.70.10.01.02.03.70, C.70.10.01.02.03.80, C.70.10.01.02.02.70 | 0d |  | Recurso Lacramarca [916973 h]; Recurso Lacramarca - NLU [7702.62 h] | 916,973.32 | N |
| C.70.10.02.03.02.80 |  | Enrocado de Talud (C1) - 4to Tramo |  | 61d | 2025-03-30 | 2025-05-29 | C.70.10.02.03.02.60 SS+3d, C.70.10.02.03.02.10, C.70.10.01.02.03.70, C.70.10.01.02.03.80, C.70.10.02.03.02.70 SS+2d, C.70.10.01.02.02.80 | 0d |  | Recurso Lacramarca [1018934 h]; Recurso Lacramarca - NLU [8279.32 h] | 1,018,934.01 | N1 |
|  | 13 | **CANALIZACIÓN** |  |  | 2025-03-19 | 2025-05-08 |  |  |  |  |  |  |
| C.70.13.10 |  | Canal C2 - 1er Tramo |  | 15d | 2025-03-19 | 2025-04-02 | C.70.10.02.01.70, C.70.01.01, C.70.10.02.01.80, C.70.10.02.01.10, C.70.10.02.01.20, C.70.10.02.01.50, C.70.10.02.01.30, C.70.10.02.01.40, C.70.10.02.01.60 | 21d | 0d | Recurso Lacramarca [1438692 h]; Recurso Lacramarca - NLU [15164.6 h] | 1,438,691.53 |  |
| C.70.13.20 |  | Canal C2 - 2do Tramo |  | 15d | 2025-04-03 | 2025-04-17 | C.70.13.10, C.70.10.02.01.10, C.70.10.02.01.20, C.70.10.02.01.50, C.70.10.02.01.30, C.70.10.02.01.40, C.70.10.02.01.60, C.70.10.02.01.70, C.70.10.02.01.80 | 21d | 0d | Recurso Lacramarca [264664 h]; Recurso Lacramarca - NLU [2294.5 h] | 264,664.22 |  |
| C.70.13.30 |  | Rampas |  | 21d | 2025-04-18 | 2025-05-08 | C.70.13.20, C.70.13.10, C.70.10.02.01.10, C.70.10.02.01.20, C.70.10.02.01.50, C.70.10.02.01.30, C.70.10.02.01.40, C.70.10.02.01.60, C.70.10.02.01.70, C.70.10.02.01.80 | 21d |  | Recurso Lacramarca [26552.7 h]; Recurso Lacramarca - NLU [137.82 h] | 26,552.67 |  |
|  | 17 | **ESTRUCTURA DE CRUCE** |  |  | 2025-01-21 | 2025-05-28 |  |  |  |  |  |  |
| C.70.17.30 |  | Sifón Integrador (Km 21+772) |  | 30d | 2025-01-21 | 2025-02-19 | C.70.10.01.01.70, C.70.10.01.01.80, C.70.01.01 | 9d | 8d | Recurso Lacramarca [101809 h]; Recurso Lacramarca - NLU [714.44 h] | 101,809.34 |  |
| C.70.17.10 |  | Captación (Km 21+079.91) |  | 30d | 2025-02-28 | 2025-03-29 | C.70.17.30, C.70.10.02.01.10, C.70.10.02.01.20, C.70.10.02.01.50, C.70.01.01 | 1d | 0d | Recurso Lacramarca [428286 h]; Recurso Lacramarca - NLU [4339.73 h] | 428,286.31 |  |
| C.70.17.40 |  | Captación (Km 23+946.16) |  | 30d | 2025-03-30 | 2025-04-28 | C.70.17.10, C.70.01.01, C.70.10.02.01.70, C.70.10.02.01.80 | 1d | 0d | Recurso Lacramarca [1031721 h]; Recurso Lacramarca - NLU [9332.12 h] | 1,031,721.26 |  |
| C.70.17.20 |  | Retorno (Km 21+547.54) |  | 30d | 2025-04-29 | 2025-05-28 | C.70.17.40, C.70.01.01 | 1d |  | Recurso Lacramarca [224586 h]; Recurso Lacramarca - NLU [1497.48 h] | 224,586.48 |  |
|  | T | **CIERRE** |  |  | 2025-01-14 | 2025-05-29 |  |  |  |  |  |  |
|  | 20 | **DESMOVILIZACIÓN** |  |  | 2025-01-14 | 2025-05-29 |  |  |  |  |  |  |
|  | 20 | **DESMOVILIZACIÓN** |  |  | 2025-01-14 | 2025-05-29 |  |  |  |  |  |  |
| T.20.20.01 |  | Programa de cierre de la obra | level of effort | 136d | 2025-01-14 | 2025-05-29 | C.70.10.02.02.70, C.70.10.02.02.80, C.70.10.01.01.70, C.70.10.01.01.80, C.70.10.01.02.01.70, C.70.10.01.02.01.80, C.70.10.01.02.02.70, C.70.10.01.02.02.80, C.70.10.01.02.03.70, C.70.10.01.02.03.80, C.70.10.02.01.70, C.70.10.02.01.80 | 0d |  | Recurso Lacramarca [1592252 h]; Recurso Lacramarca - NLU [5951.43 h] | 1,592,252.36 |  |

## Activity codes

| Code | Value | Meaning |
| --- | --- | --- |
| Lacramarca | D | Descolmatación |
| Lacramarca | E | Excavación |
| Lacramarca | E1 | Excavación de Uña |
| Lacramarca | G | Geotextil |
| Lacramarca | N | Enrocado de Uña |
| Lacramarca | N1 | Enrocado de Talud |
| Lacramarca | R | Relleno de Cuerpo |
| Lacramarca | R1 | Relleno de Corona |
